# CMS_alim_UPS-v1.1

Schedule from MS Project, 2013-02-25 to 2013-04-26.
CERN

## Calendars

- Standard: Mon-Fri 08:00-12:00, 13:00-17:00; Sat-Sun off.

## Resources

| Resource |
| --- |
| EN-EL |
| CMS |
| GS-ASE |
| EN-EL(ABB) |
| EN-EL(Spie) |

## Schedule

| ID | WBS | Task | Type | Duration | Start | Finish | Total slack | Constraint | Resources | Work |
| --- | --- | --- | --- | --- | --- | --- | --- | --- | --- | --- |
| 1 | 1 | **Consolidation alimentation racks CMS en USC55** |  | 45d | 2013-02-25 | 2013-04-26 | 0d |  |  | 720h |
| 2 | 1.1 | Réseau UPS racks USC55 en service (UPS 60+20 kVA) | manual | 45d | 2013-02-25 | 2013-04-26 |  |  |  |  |
| 3 | 1.2 | **Coupures de réseaux** |  | 25d | 2013-03-25 | 2013-04-26 | 0d |  |  |  |
| 4 | 1.2.1 | Réseau LV UPS Detecteur UXC55 | manual | 15d | 2013-04-08 | 2013-04-26 |  |  |  |  |
| 5 | 1.2.2 | Réseau Racks CMS + laser room + salle gaz en USC55 | manual | 25d | 2013-03-25 | 2013-04-26 |  |  |  |  |
| 6 | 1.3 | **Travaux cablage** |  | 20d | 2013-02-25 | 2013-03-22 | 0d |  |  | 200h |
| 7 | 1.3.1 | Installation echaffaudages en tete de puits PM54 | manual | 5d | 2013-02-25 | 2013-03-01 |  |  | CMS | 40h |
| 8 | 1.3.2 | pose echelles a cables en tete de puits PM54 | manual | 5d | 2013-03-04 | 2013-03-08 |  | start no earlier than 2013-03-04 | EN-EL(Spie) | 40h |
| 9 | 1.3.3 | pose echelles a cables en fond de puits PM54 | manual | 5d | 2013-03-04 | 2013-03-08 |  |  | EN-EL(Spie) | 40h |
| 10 | 1.3.4 | Tirage de 1 km de cable 240mm2 | manual | 10d | 2013-03-11 | 2013-03-22 |  |  | EN-EL(Spie) | 80h |
| 11 | 1.4 | **Modification des tableaux** |  | 40d | 2013-02-25 | 2013-04-19 | 0d |  |  | 520h |
| 12 | 1.4.1 | Depose partielle Detection Incendie local UPS en SDX5 | manual | 5d | 2013-02-25 | 2013-03-01 |  |  | GS-ASE | 40h |
| 13 | 1.4.2 | Modification tableau EXD2/55 (USC55) | manual | 5d | 2013-03-25 | 2013-03-29 |  |  | EN-EL(ABB) | 40h |
| 14 | 1.4.3 | Modification tableau EXD1/55 (USC55) | manual | 5d | 2013-04-01 | 2013-04-05 |  |  | EN-EL(ABB) | 40h |
| 15 | 1.4.4 | Modification tableau EXD2/5DX (SD5) | manual | 5d | 2013-04-08 | 2013-04-12 |  |  | EN-EL(ABB) | 40h |
| 16 | 1.4.5 | Modification structure metalique pour EXD2/55 | manual | 5d | 2013-02-25 | 2013-03-01 |  |  | CMS | 40h |
| 17 | 1.4.6 | Pose et raccordement sur boite jonction EXD1/55 | manual | 10d | 2013-03-25 | 2013-04-05 |  |  | EN-EL(Spie) | 80h |
| 18 | 1.4.7 | Deplacement cables tfo-tableau EXD1/55 et liaison EXD1/55 et EXD2/55 | manual | 15d | 2013-04-01 | 2013-04-19 |  |  | EN-EL(Spie) | 120h |
| 19 | 1.4.8 | Raccordements des cables sur les differentes armoires modifiées | manual | 15d | 2013-04-01 | 2013-04-19 |  |  | EN-EL(Spie) | 120h |
| 20 | 2 | Tests, commissioning et mise en service | manual | 5d | 2013-04-22 | 2013-04-26 |  |  | EN-EL | 40h |
